# Tiến độ thi công

Schedule from MS Project, 2025-05-02 to 2025-09-03.

## Calendars

- Standard: Mon-Fri 08:00-12:00, 13:00-17:00; Sat-Sun off.

## Schedule

| ID | WBS | Task | Duration | Start | Finish | Predecessors | Total slack | Free slack | Constraint |
| --- | --- | --- | --- | --- | --- | --- | --- | --- | --- |
| 1 | 1 | **TIẾN ĐỘ TỔNG** | 89d | 2025-05-02 | 2025-09-03 |  | 0d |  |  |
| 2 | 1.1 | **GIAI ĐOẠN CHUẨN BỊ** | 12d | 2025-05-02 | 2025-05-19 |  | 0d |  |  |
| 3 | 1.1.1 | Nhận bàn giao mặt bằng | 2d | 2025-05-02 | 2025-05-05 |  | 0d |  | start no earlier than 2025-05-02 |
| 4 | 1.1.2 | Trình mẫu vật tư, thiết bị | 7d | 2025-05-06 | 2025-05-14 | 3 | 80d | 0d | start no earlier than 2025-05-02 |
| 5 | 1.1.3 | Triển khai bản vẽ shopdrawing | 10d | 2025-05-06 | 2025-05-19 | 3 | 77d |  |  |
| 6 | 1.1.4 | Xây dựng kho bãi, văn phòng dự án | 4d | 2025-05-06 | 2025-05-09 | 3 | 83d |  |  |
| 7 | 1.2 | **THI CÔNG PHẦN THÔ** | 67d | 2025-05-06 | 2025-08-06 |  | 0d |  |  |
| 8 | 1.2.1 | Định vị tuyến, cắm tim móng cột, xác định vị trí đặt tủ điện | 2d | 2025-05-06 | 2025-05-07 | 3 | 0d |  |  |
| 9 | 1.2.2 | Nhận bàn giao tuyến ống đã thi công từ nhà thầu thi công hạ tầng | 3d | 2025-05-08 | 2025-05-12 | 8 | 79d | 0d |  |
| 10 | 1.2.3 | Thông ống đã nhận bàn giao | 3d | 2025-05-13 | 2025-05-15 | 9 | 79d |  |  |
| 11 | 1.2.4 | Tập kết vật tư | 3d | 2025-05-12 | 2025-05-14 | 4SS+4d | 80d |  |  |
| 12 | 1.2.5 | Thi công đào hố móng tủ điện, móng trụ,đào rãnh cáp | 25d | 2025-05-08 | 2025-06-11 | 8 | 0d |  |  |
| 13 | 1.2.6 | Ghép cốp pha, đổ móng tủ điện, móng trụ đèn | 7d | 2025-06-12 | 2025-06-20 | 12 | 0d |  |  |
| 14 | 1.2.7 | Lắp đặt ống âm, lắp đặt móng tủ, móng trụ, lấp hoàn trả mặt bằng | 15d | 2025-06-23 | 2025-07-11 | 13 | 0d |  |  |
| 15 | 1.2.8 | Bàn giao xây dựng thực hiện công tác hoàn thiện | 2d | 2025-07-14 | 2025-07-15 | 14 | 0d |  |  |
| 16 | 1.2.9 | Kéo rãi cáp điện | 13d | 2025-07-16 | 2025-08-01 | 15 | 0d |  |  |
| 17 | 1.2.10 | Testing thông mạch, cách điện cáp | 3d | 2025-08-04 | 2025-08-06 | 16 | 0d |  |  |
| 18 | 1.3 | **LẮP ĐẶT THIẾT BỊ** | 13d | 2025-08-07 | 2025-08-25 |  | 0d |  |  |
| 19 | 1.3.1 | Lắp đặt đèn trụ 4m, 7m | 7d | 2025-08-07 | 2025-08-15 | 17 | 0d |  |  |
| 20 | 1.3.2 | Lắp đặt thiết bị đèn sân vườn: đèn Bollard, đèn chiếu cây, led dây | 4d | 2025-08-18 | 2025-08-21 | 19 | 0d |  |  |
| 21 | 1.3.3 | Lắp đặt tủ điện, đấu nối | 2d | 2025-08-22 | 2025-08-25 | 20 | 0d |  |  |
| 22 | 1.4 | **KIỂM TRA VẬN HÀNH VÀ BÀN GIAO** | 9d | 2025-08-22 | 2025-09-03 |  | 0d |  |  |
| 23 | 1.4.1 | Kiểm tra vận hành thử, sửa lỗi | 2d | 2025-08-22 | 2025-08-25 | 21SS | 0d |  |  |
| 24 | 1.4.2 | Bản vẽ hoàn công, hướng dẫn sử dụng | 4d | 2025-08-22 | 2025-08-27 | 23SS | 0d |  |  |
| 25 | 1.4.3 | Hồ sơ bàn giao đưa vào sử dụng và quyết toán | 5d | 2025-08-28 | 2025-09-03 | 24 | 0d |  |  |
